# Védőfal1

Schedule from MS Project, 2007-10-01 to 2007-11-13, costs in Ft.
WSH Kft

## Calendars

- Standard: Mon-Fri 08:00-12:00, 13:00-17:00; Sat-Sun off.
- Utókezelés: Mon-Sun 08:00-09:00.

## Resources

| Resource | Rate |
| --- | --- |
| Segédmunkás | 1000 |
| Kőműves | 1500 |
| Zsaluanyag |  |
| FS Bt. | 2500 |
| Kertész | 1100 |
| Kerítéselemek |  |

## Schedule

| ID | WBS | Task | Type | Duration | Start | Finish | Predecessors | Total slack | Free slack | Constraint | Deadline | Resources | Work | Cost |
| --- | --- | --- | --- | --- | --- | --- | --- | --- | --- | --- | --- | --- | --- | --- |
| 1 | 1 | **Raktárak korszerűsítése** |  | 26d? | 2007-10-01 | 2007-11-05 |  | -1d | 0d |  |  |  | 1656h | 2,164,000 |
| 2 | 1.1 | Tereprendezés |  | 6d | 2007-10-01 | 2007-10-08 |  | -1d | 0d |  |  | Segédmunkás [600%] | 288h | 288,000 |
| 3 | 1.2 | Tereprendezés kész | milestone | 0d | 2007-10-08 | 2007-10-08 | 2 | -1d | 0d |  | 2007-10-05 |  |  |  |
| 4 | 1.3 | Szükséges anyagok és eszközök kiszállítása |  | 1d | 2007-10-09 | 2007-10-09 | 3 | 0d |  |  |  | Segédmunkás [200%] | 16h | 16,000 |
| 5 | 1.4 | Felvonulási épület felállítása |  | 2d | 2007-10-10 | 2007-10-11 | 4 | 0d |  |  |  | Segédmunkás [200%]; Kőműves | 48h | 56,000 |
| 6 | 1.5 | .Felvonulási épület elkészült | milestone | 0d | 2007-10-11 | 2007-10-11 | 5 | 0d |  |  |  |  |  |  |
| 7 | 1.6 | A kiürített raktár átvétele | milestone | 0d | 2007-10-02 | 2007-10-02 |  | 8d | 5d | finish no earlier than 2007-10-02 |  |  |  |  |
| 8 | 1.7 | Falak megerősítése |  | 4d | 2007-10-10 | 2007-10-15 | 7, 4 | 11d | 0d |  |  | Kőműves [200%]; Segédmunkás [600%] | 256h | 288,000 |
| 9 | 1.8 | -S1 |  | 1d? | 2007-10-16 | 2007-10-16 | 8 | 14d | 0d |  |  |  |  |  |
| 10 | 1.9 | Nyílászárók cseréje |  | 3d | 2007-10-12 | 2007-10-16 | 8SS+1d, 9FF | 11d |  |  |  | Kőműves; Segédmunkás [200%] | 72h | 84,000 |
| 11 | 1.10 | Belső terek szabvány szerinti átalakítása |  | 12d | 2007-10-10 | 2007-10-25 | 7, 4 | 0d |  |  |  | Kőműves [200%]; Segédmunkás [600%] | 768h | 864,000 |
| 12 | 1.11 | Tűzoltórendszer átalakítása |  | 4d | 2007-10-26 | 2007-10-31 | 8, 11 | 0d |  |  |  | FS Bt. [500%] | 160h | 400,000 |
| 13 | 1.12 | Új biztonsági rendszer kiépítése |  | 3d | 2007-11-01 | 2007-11-05 | 10, 12 | 0d |  |  |  | FS Bt. [200%] | 48h | 168,000 |
| 14 | 1.13 | Korszerűsítés kész | milestone | 0d | 2007-11-05 | 2007-11-05 | 13 | 3d |  |  | 2007-11-08 |  |  |  |
| 15 | 1.14 | .Kiszámlázhatók a korszerűsítési munkálatok | milestone | 0d | 2007-11-05 | 2007-11-05 | 13 | 0d |  |  |  |  |  |  |
| 16 | 2 | Döntés a védőfalépítés megkezdéséről | milestone | 0d | 2007-10-11 | 2007-10-11 |  | 0d |  | finish no earlier than 2007-10-11 |  |  |  |  |
| 17 | 3 | **Védőfal elkészítése** |  | 21d | 2007-10-12 | 2007-11-11 | 16 | 0d |  |  |  |  | 600h | 668,000 |
| 18 | 3.1 | Szükséges anyagok és eszközök kiszállítása |  | 1d | 2007-10-12 | 2007-10-12 |  | 0d |  |  |  | Segédmunkás [200%] | 16h | 16,000 |
| 19 | 3.2 | Ideiglenes kerítés építése |  | 4d | 2007-10-15 | 2007-10-18 | 18, 3 | 0d |  |  |  | Segédmunkás [300%]; Kőműves | 128h | 144,000 |
| 20 | 3.3 | Régi kerítés lebontása |  | 1d | 2007-10-19 | 2007-10-19 | 19 | 0d |  |  |  | Segédmunkás [200%] | 16h | 16,000 |
| 21 | 3.4 | Alapásás |  | 1d | 2007-10-22 | 2007-10-22 | 20 | 0d |  |  |  | Segédmunkás [500%] | 40h | 40,000 |
| 22 | 3.5 | Vasszerelés |  | 2d | 2007-10-23 | 2007-10-24 | 21 | 0d |  |  |  | Segédmunkás [300%]; Kőműves | 64h | 72,000 |
| 23 | 3.6 | Ellenőrzés | milestone | 0d | 2007-10-24 | 2007-10-24 | 22 | 0d |  | finish no earlier than 2007-10-24 | 2007-10-24 |  |  |  |
| 24 | 3.7 | Zsaluzás |  | 5d | 2007-10-25 | 2007-10-31 | 23 | 0d |  |  |  | Kőműves; Segédmunkás [300%] | 160h | 180,000 |

| ID | WBS | Task | Type | Duration | Start | Finish | Predecessors | Total slack | Deadline | Calendar | Resources | Work | Cost |
| --- | --- | --- | --- | --- | --- | --- | --- | --- | --- | --- | --- | --- | --- |
| 25 | 3.8 | **:Betonozás** |  | 5d | 2007-10-25 | 2007-11-01 |  | 0d |  |  | Kőműves; Segédmunkás [300%] | 160h | 180,000 |
| 26 | 3.8.1 | Betonozás kezdete | milestone | 0d | 2007-10-25 | 2007-10-25 | 24SS+1d | 5d |  |  |  |  |  |
| 27 | 3.8.2 | Betonozás vége | milestone | 0d | 2007-11-01 | 2007-11-01 | 24FS+1d | 0d |  |  |  |  |  |
| 28 | 3.9 | **Utókezelés** |  | 1.25d | 2007-11-02 | 2007-11-11 |  | 0d |  | Utókezelés |  |  |  |
| 29 | 3.9.1 | Utókezelés 1 |  | 1h | 2007-11-02 | 2007-11-02 | 25 | 0d |  | Utókezelés |  |  |  |
| 30 | 3.9.2 | Utókezelés 2 |  | 1h | 2007-11-03 | 2007-11-03 | 29 | 0d |  | Utókezelés |  |  |  |
| 31 | 3.9.3 | Utókezelés 3 |  | 1h | 2007-11-04 | 2007-11-04 | 30 | 0d |  | Utókezelés |  |  |  |
| 32 | 3.9.4 | Utókezelés 4 |  | 1h | 2007-11-05 | 2007-11-05 | 31 | 0d |  | Utókezelés |  |  |  |
| 33 | 3.9.5 | Utókezelés 5 |  | 1h | 2007-11-06 | 2007-11-06 | 32 | 0d |  | Utókezelés |  |  |  |
| 34 | 3.9.6 | Utókezelés 6 |  | 1h | 2007-11-07 | 2007-11-07 | 33 | 0d |  | Utókezelés |  |  |  |
| 35 | 3.9.7 | Utókezelés 7 |  | 1h | 2007-11-08 | 2007-11-08 | 34 | 0d |  | Utókezelés |  |  |  |
| 36 | 3.9.8 | Utókezelés 8 |  | 1h | 2007-11-09 | 2007-11-09 | 35 | 0d |  | Utókezelés |  |  |  |
| 37 | 3.9.9 | Utókezelés 9 |  | 1h | 2007-11-10 | 2007-11-10 | 36 | 0d |  | Utókezelés |  |  |  |
| 38 | 3.9.10 | Utókezelés 10 |  | 1h | 2007-11-11 | 2007-11-11 | 37 | 0d |  | Utókezelés |  |  |  |
| 39 | 3.10 | ! Kizsaluzhatósági idő |  | 3ed | 2007-11-01 | 2007-11-04 | 25 | 1.88d |  |  |  |  |  |
| 40 | 3.11 | Kizsaluzás |  | 1d | 2007-11-05 | 2007-11-05 | 39 | 0d |  |  | Segédmunkás; Kőműves | 16h | 20,000 |
| 41 | 3.12 | Védőkerítés kész | milestone | 0d | 2007-11-05 | 2007-11-05 | 40 | 0d | 2007-11-16 |  |  |  |  |
| 42 | 3.13 | .Kiszámlázhatóak a védőfallal kapcsolatos munkálatok | milestone | 0d | 2007-11-05 | 2007-11-05 | 40 | 0d |  |  |  |  |  |
| 43 | 4 | **Utómunkálatok** |  | 6d | 2007-11-06 | 2007-11-13 |  | 0d |  |  |  | 320h | 323,200 |
| 44 | 4.1 | Felvonulási épület lebontása |  | 2d | 2007-11-07 | 2007-11-08 | 5, 47FF | 0d |  |  | Segédmunkás [300%] | 48h | 48,000 |
| 45 | 4.2 | Építkezési törmelék elszállítása |  | 2d | 2007-11-06 | 2007-11-07 | 41 | 0d |  |  | Segédmunkás [400%] | 64h | 64,000 |
| 46 | 4.3 | Ideiglenes kerítés elbontása |  | 1d | 2007-11-08 | 2007-11-08 | 45 | 0d |  |  | Segédmunkás [200%] | 16h | 16,000 |
| 47 | 4.4 | Átadás | milestone | 0d | 2007-11-08 | 2007-11-08 | 14, 46 | 0d | 2007-11-23 |  |  |  |  |
| 48 | 4.5 | Tereprendezés |  | 2d | 2007-11-08 | 2007-11-09 | 45 | 0d |  |  | Segédmunkás [600%] | 96h | 96,000 |
| 49 | 4.6 | Fák ültetése |  | 2d | 2007-11-12 | 2007-11-13 | 48 | 0d |  |  | Kertész [200%]; Segédmunkás [400%] | 96h | 99,200 |

| ID | WBS | Task | Type | Duration | Start | Finish | Predecessors | Total slack | Resources | Work |
| --- | --- | --- | --- | --- | --- | --- | --- | --- | --- | --- |
| 50 | 5 | **Erőforrás-foglalásitevékenységek** |  | 19d | 2007-10-15 | 2007-11-08 |  | 0d |  | 216h |
| 51 | 5.1 | **:Zsaluanyagok foglalása** |  | 8d | 2007-10-25 | 2007-11-05 |  | 0d | Zsaluanyag | 64h |
| 52 | 5.1.1 | FK | milestone | 0d | 2007-10-25 | 2007-10-25 | 24SS | 0d |  |  |
| 53 | 5.1.2 | FV | milestone | 0d | 2007-11-05 | 2007-11-05 | 40 | 0d |  |  |
| 54 | 5.2 | **:Ideiglenes kerítéselemek foglalása** |  | 19d | 2007-10-15 | 2007-11-08 |  | 0d | Kerítéselemek | 152h |
| 55 | 5.2.1 | FK | milestone | 0d | 2007-10-15 | 2007-10-15 | 19SS | 0d |  |  |
| 56 | 5.2.2 | FV | milestone | 0d | 2007-11-08 | 2007-11-08 | 46 | 0d |  |  |
